| TaskID | TaskName | StartDate | EndDate | Duration | Progress | DurationUnit | Predecessor |
| --- | --- | --- | --- | --- | --- | --- | --- |
| 1 | Zákazník | 2022-02-01T07:00:00.000Z | 2022-10-19T14:00:00.000Z | 186.875 | 0 | day |  |
| 2 | · Vytvoření zakázky | 2022-02-01T07:00:00.000Z | 2022-02-02T16:00:00.000Z | 2 | 0 | day |  |
| 3 | · Odeslání všech potřebných podkladů | 2022-02-03T07:00:00.000Z | 2022-02-03T08:00:00.000Z | 1 | 0 | hour | 2FS |
| 4 | · Schválení prezentace | 2022-02-08T12:00:00.000Z | 2022-02-15T11:00:00.000Z | 5 | 0 | day | 33FS |
| 5 | · Úprava požadavků zakázky | 2022-02-15T12:00:00.000Z | 2022-02-18T11:00:00.000Z | 3 | 0 | day | 4FS |
| 6 | · Odeslání všech potřebných podkladů | 2022-02-18T12:00:00.000Z | 2022-02-18T13:00:00.000Z | 1 | 0 | hour | 5FS |
| 95 | · Schválení prezentace | 2022-02-24T07:00:00.000Z | 2022-04-06T15:00:00.000Z | 30 | 0 | day | 36FS |
| 7 | · Kontaktování dodavatele | 2022-04-07T06:00:00.000Z | 2022-04-07T07:00:00.000Z | 1 | 0 | hour | 95FS |
| 8 | · Změna zakázky | 2022-05-02T13:00:00.000Z | 2022-05-16T13:00:00.000Z | 10 | 0 | day | 60FS |
| 9 | · Odeslání všech potřebných podkladů | 2022-05-16T13:00:00.000Z | 2022-05-16T14:00:00.000Z | 1 | 0 | hour | 8FS |
| 96 | · Schválení prezentace | 2022-05-20T08:00:00.000Z | 2022-07-01T08:00:00.000Z | 30 | 0 | day | 39FS |
| 97 | · Kontaktování dodavatele | 2022-07-01T08:00:00.000Z | 2022-07-01T09:00:00.000Z | 1 | 0 | hour | 96FS |
| 10 | · Přijetí nabídky | 2022-07-27T06:00:00.000Z | 2022-08-15T15:00:00.000Z | 14 | 0 | day | 70FS |
| 11 | · Kontaktování dodavatele | 2022-08-16T06:00:00.000Z | 2022-08-16T07:00:00.000Z | 1 | 0 | hour | 10FS |
| 12 | · Zaplacení zálohové faktury | 2022-08-17T08:00:00.000Z | 2022-08-18T08:00:00.000Z | 1 | 0 | day | 72FS |
| 13 | · Předání zákázky a zaplacení finální faktury | 2022-10-18T14:00:00.000Z | 2022-10-19T14:00:00.000Z | 1 | 0 | day | 75FS |
| 14 | Brumlovka | 2022-02-03T09:00:00.000Z | 2022-10-18T12:00:00.000Z | 183.375 | 0 | day |  |
| 15 | · Zjištění možnosti upevnění | 2022-02-03T09:00:00.000Z | 2022-02-03T14:00:00.000Z | 4 | 0 | hour | 28FS |
| 16 | · Kontaktování GT oddělení ohledně upevnění | 2022-02-03T14:00:00.000Z | 2022-02-03T15:00:00.000Z | 1 | 0 | hour | 15FS |
| 44 | · Zjištění možnosti upevnění | 2022-02-18T14:00:00.000Z | 2022-02-21T09:00:00.000Z | 4 | 0 | hour | 40FS |
| 45 | · Kontaktování GT oddělení ohledně upevnění | 2022-02-21T09:00:00.000Z | 2022-02-21T10:00:00.000Z | 1 | 0 | hour | 44FS |
| 46 | · Zjištění možnosti upevnění | 2022-05-17T06:00:00.000Z | 2022-05-17T10:00:00.000Z | 4 | 0 | hour | 42FS |
| 47 | · Kontaktování GT oddělení ohledně upevnění | 2022-05-17T11:00:00.000Z | 2022-05-17T12:00:00.000Z | 1 | 0 | hour | 46FS |
| 17 | · Příjezd písmen | 2022-10-04T14:00:00.000Z | 2022-10-05T07:00:00.000Z | 2 | 0 | hour | 91FS |
| 18 | · Příprava výškového pracovníka | 2022-10-05T06:00:00.000Z | 2022-10-05T07:00:00.000Z | 1 | 0 | hour | 43FS |
| 19 | · Instalace písmen | 2022-10-05T07:00:00.000Z | 2022-10-14T08:00:00.000Z | 7.125 | 0 | day |  |
| 20 | · · Ukotvení korpusů písmen na fasádu | 2022-10-05T07:00:00.000Z | 2022-10-12T07:00:00.000Z | 5 | 0 | day | 17FS,18FS |
| 21 | · · Připojení elektriky | 2022-10-12T07:00:00.000Z | 2022-10-13T07:00:00.000Z | 1 | 0 | day | 20FS |
| 22 | · · Zavíkování písmen | 2022-10-13T07:00:00.000Z | 2022-10-14T07:00:00.000Z | 1 | 0 | day | 21FS |
| 23 | · · Rozsvícení písmen | 2022-10-14T07:00:00.000Z | 2022-10-14T08:00:00.000Z | 1 | 0 | hour | 22FS |
| 24 | · Oprava chyb při instalaci | 2022-10-14T08:00:00.000Z | 2022-10-18T08:00:00.000Z | 2 | 0 | day | 23FS |
| 25 | · Vytvoření reportu ohledně vyskytnutých chyb | 2022-10-18T08:00:00.000Z | 2022-10-18T10:00:00.000Z | 2 | 0 | hour | 24FS |
| 26 | · Kontaktování obch. oddělení | 2022-10-18T11:00:00.000Z | 2022-10-18T12:00:00.000Z | 1 | 0 | hour | 25FS |
| 27 | Výškový pracovník | 2022-02-03T08:00:00.000Z | 2022-10-04T15:00:00.000Z | 173.875 | 0 | day |  |
| 28 | · Odjezd na místo určení | 2022-02-03T08:00:00.000Z | 2022-02-03T09:00:00.000Z | 1 | 0 | hour | 3FS |
| 40 | · Odjezd na místo určení | 2022-02-18T13:00:00.000Z | 2022-02-18T14:00:00.000Z | 1 | 0 | hour | 6FS |
| 42 | · Odjezd na místo určení | 2022-05-16T14:00:00.000Z | 2022-05-16T15:00:00.000Z | 1 | 0 | hour | 9FS |
| 43 | · Odjezd na místo | 2022-10-04T14:00:00.000Z | 2022-10-04T15:00:00.000Z | 1 | 0 | hour | 91FS |
| 30 | Graficko-technické oddělení | 2022-02-03T08:00:00.000Z | 2022-08-25T08:00:00.000Z | 145.125 | 0 | day |  |
| 31 | · Vizualizace finálního produktu | 2022-02-03T08:00:00.000Z | 2022-02-07T08:00:00.000Z | 2 | 0 | day | 3FS |
| 32 | · Tvorba prezentace | 2022-02-07T08:00:00.000Z | 2022-02-08T08:00:00.000Z | 1 | 0 | day | 31FS,16FS |
| 33 | · Předvedení zákazníkovi | 2022-02-08T08:00:00.000Z | 2022-02-08T11:00:00.000Z | 3 | 0 | hour | 32FS |
| 34 | · Vizualizace finálního produktu | 2022-02-18T13:00:00.000Z | 2022-02-22T13:00:00.000Z | 2 | 0 | day | 6FS |
| 35 | · Tvorba prezentace | 2022-02-22T13:00:00.000Z | 2022-02-23T13:00:00.000Z | 1 | 0 | day | 34FS,45FS |
| 36 | · Předvedení zákazníkovi | 2022-02-23T13:00:00.000Z | 2022-02-23T16:00:00.000Z | 3 | 0 | hour | 35FS |
| 37 | · Vizualizace finálního produktu | 2022-05-16T14:00:00.000Z | 2022-05-18T14:00:00.000Z | 2 | 0 | day | 9FS |
| 38 | · Tvorba prezentace | 2022-05-18T14:00:00.000Z | 2022-05-19T14:00:00.000Z | 1 | 0 | day | 47FS,37FS |
| 39 | · Předvedení zákazníkovi | 2022-05-19T14:00:00.000Z | 2022-05-20T08:00:00.000Z | 3 | 0 | hour | 38FS |
| 49 | · Tvorba grafických a technických podkladů | 2022-08-16T07:00:00.000Z | 2022-08-25T07:00:00.000Z | 7 | 0 | day | 11FS |
| 50 | · Odeslání podkladů na frézu a kovovýrobu | 2022-08-25T07:00:00.000Z | 2022-08-25T08:00:00.000Z | 1 | 0 | hour | 49FS |
| 48 | Obchodní oddělení | 2022-04-07T07:00:00.000Z | 2022-10-18T14:00:00.000Z | 138.75 | 0 | day |  |
| 51 | · Kontakotvání úřadů | 2022-04-07T07:00:00.000Z | 2022-04-28T07:00:00.000Z | 15 | 0 | day |  |
| 52 | · · Kontaktování policie ČR | 2022-04-07T07:00:00.000Z | 2022-04-08T07:00:00.000Z | 1 | 0 | day | 7FS |
| 53 | · · Obdržení povolení od Polici ČR | 2022-04-08T07:00:00.000Z | 2022-04-28T07:00:00.000Z | 14 | 0 | day | 52FS |
| 54 | · · Kontaktování stavebního úřadu | 2022-04-07T07:00:00.000Z | 2022-04-08T07:00:00.000Z | 1 | 0 | day | 7FS |
| 55 | · · Obdržení stavebího povolení | 2022-04-08T07:00:00.000Z | 2022-04-28T07:00:00.000Z | 14 | 0 | day | 54FS |
| 56 | · · Kontakotvání statika | 2022-04-07T07:00:00.000Z | 2022-04-08T07:00:00.000Z | 1 | 0 | day | 7FS |
| 57 | · · Obdržení zprávy od statika | 2022-04-08T07:00:00.000Z | 2022-04-28T07:00:00.000Z | 14 | 0 | day | 56FS |
| 58 | · Kontrola dokumentů | 2022-04-28T07:00:00.000Z | 2022-04-28T12:00:00.000Z | 4 | 0 | hour | 53FS,55FS,57FS |
| 59 | · Tvorba technické dokumentace | 2022-04-28T12:00:00.000Z | 2022-05-02T12:00:00.000Z | 2 | 0 | day | 58FS |
| 60 | · Odeslání technické dokumentace zákazníkovi | 2022-05-02T12:00:00.000Z | 2022-05-02T13:00:00.000Z | 1 | 0 | hour | 59FS |
| 61 | · Kontakotvání úřadů | 2022-07-01T09:00:00.000Z | 2022-07-22T09:00:00.000Z | 15 | 0 | day |  |
| 62 | · · Kontaktování policie ČR | 2022-07-01T09:00:00.000Z | 2022-07-04T09:00:00.000Z | 1 | 0 | day | 97FS |
| 63 | · · Obdržení povolení od Polici ČR | 2022-07-04T09:00:00.000Z | 2022-07-22T09:00:00.000Z | 14 | 0 | day | 62FS |
| 64 | · · Kontaktování stavebního úřadu | 2022-07-01T09:00:00.000Z | 2022-07-04T09:00:00.000Z | 1 | 0 | day | 97FS |
| 65 | · · Obdržení stavebího povolení | 2022-07-04T09:00:00.000Z | 2022-07-22T09:00:00.000Z | 14 | 0 | day | 64FS |
| 66 | · · Kontakotvání statika | 2022-07-01T09:00:00.000Z | 2022-07-04T09:00:00.000Z | 1 | 0 | day | 97FS |
| 67 | · · Obdržení zprávy od statika | 2022-07-04T09:00:00.000Z | 2022-07-22T09:00:00.000Z | 14 | 0 | day | 66FS |
| 68 | · Kontrola dokumentů | 2022-07-22T09:00:00.000Z | 2022-07-22T14:00:00.000Z | 4 | 0 | hour | 63FS,65FS,67FS |
| 69 | · Tvorba technické dokumentace | 2022-07-22T14:00:00.000Z | 2022-07-26T14:00:00.000Z | 2 | 0 | day | 68FS |

| TaskID | TaskName | StartDate | EndDate | Duration | Progress | DurationUnit | Predecessor |
| --- | --- | --- | --- | --- | --- | --- | --- |
| 70 | · Odeslání technické dokumentace zákazníkovi | 2022-07-26T14:00:00.000Z | 2022-07-26T15:00:00.000Z | 1 | 0 | hour | 69FS |
| 71 | · Tvorba finální kalkulace + záloha | 2022-08-16T07:00:00.000Z | 2022-08-17T07:00:00.000Z | 1 | 0 | day | 11FS |
| 72 | · Odeslání zálohové faktury | 2022-08-17T07:00:00.000Z | 2022-08-17T08:00:00.000Z | 1 | 0 | hour | 71FS |
| 73 | · Vytvoření finální faktury | 2022-10-18T12:00:00.000Z | 2022-10-18T13:00:00.000Z | 1 | 0 | hour | 26FS |
| 74 | · Vytvoření faktury ohledně doplatku | 2022-10-18T12:00:00.000Z | 2022-10-18T13:00:00.000Z | 1 | 0 | hour | 26FS |
| 75 | · Odeslání finální faktury zákazníkovi | 2022-10-18T13:00:00.000Z | 2022-10-18T14:00:00.000Z | 1 | 0 | hour | 73FS,74FS |
| 76 | Produkční oddělení | 2022-08-25T08:00:00.000Z | 2022-10-04T14:00:00.000Z | 28.625 | 0 | day |  |
| 77 | · Fréza a laser | 2022-08-25T08:00:00.000Z | 2022-08-31T08:00:00.000Z | 4 | 0 | day |  |
| 78 | · · Vyříznutí písmen | 2022-08-25T08:00:00.000Z | 2022-08-29T08:00:00.000Z | 2 | 0 | day | 50FS |
| 79 | · · Tvorba čel jednotlivých písmen | 2022-08-29T08:00:00.000Z | 2022-08-31T08:00:00.000Z | 2 | 0 | day | 78FS |
| 80 | · Kovovýroba | 2022-08-25T08:00:00.000Z | 2022-10-04T14:00:00.000Z | 28.625 | 0 | day |  |
| 81 | · · Tvorba nosných konstrukcí | 2022-08-25T08:00:00.000Z | 2022-09-05T08:00:00.000Z | 7 | 0 | day | 50FS |
| 82 | · · Ohýbání bočnic jednotlivých písmen | 2022-09-05T08:00:00.000Z | 2022-09-07T08:00:00.000Z | 2 | 0 | day | 79FS,81FS |
| 83 | · · Svaření jednotlivých částí | 2022-09-07T08:00:00.000Z | 2022-09-12T08:00:00.000Z | 3 | 0 | day | 82FS |
| 84 | · · Elektroinstalace | 2022-09-16T08:00:00.000Z | 2022-09-21T08:00:00.000Z | 3 | 0 | day | 94FS |
| 85 | · · Finální složení | 2022-09-21T08:00:00.000Z | 2022-09-23T08:00:00.000Z | 2 | 0 | day | 84FS |
| 86 | · · Oprava chyb | 2022-09-23T08:00:00.000Z | 2022-09-28T08:00:00.000Z | 3 | 0 | day | 85FS |
| 87 | · · Finální složení | 2022-09-28T08:00:00.000Z | 2022-09-30T08:00:00.000Z | 2 | 0 | day | 86FS |
| 88 | · · Rozebrání na menší části | 2022-09-30T08:00:00.000Z | 2022-10-03T08:00:00.000Z | 1 | 0 | day | 87FS |
| 89 | · · Příprava k převozu (zabalení) | 2022-10-03T08:00:00.000Z | 2022-10-04T08:00:00.000Z | 1 | 0 | day | 88FS |
| 90 | · · Naložení do auta | 2022-10-04T08:00:00.000Z | 2022-10-04T12:00:00.000Z | 3 | 0 | hour | 89FS |
| 91 | · · Odvoz na dané místo | 2022-10-04T12:00:00.000Z | 2022-10-04T14:00:00.000Z | 2 | 0 | hour | 90FS |
| 92 | Lakovna | 2022-09-12T08:00:00.000Z | 2022-09-16T08:00:00.000Z | 4 | 0 | day |  |
| 93 | · Lakování částí zevnitř | 2022-09-12T08:00:00.000Z | 2022-09-14T08:00:00.000Z | 2 | 0 | day | 83FS |
| 94 | · Lakování částí zvenku | 2022-09-14T08:00:00.000Z | 2022-09-16T08:00:00.000Z | 2 | 0 | day | 93FS |
