| TaskID | TaskName | Duration | DurationUnit | Progress | StartDate | EndDate | Predecessor |
| --- | --- | --- | --- | --- | --- | --- | --- |
| 1 | Zákazník | 60.5 | day | 0 | 2022-04-01T06:00:00.000Z | 2022-06-24T10:00:00.000Z |  |
| 2 | · Vytvoření zakázky | 2 | day | 0 | 2022-04-01T06:00:00.000Z | 2022-04-04T15:00:00.000Z |  |
| 3 | · Odeslání všech potřebných podkladů | 1 | hour | 0 | 2022-04-05T06:00:00.000Z | 2022-04-05T07:00:00.000Z | 2FS |
| 4 | · Schválení prezentace | 30 | day | 0 | 2022-04-21T11:00:00.000Z | 2022-06-02T10:00:00.000Z | 13FS,3FS |
| 5 | · Kontaktování dodavatele | 1 | hour | 0 | 2022-06-02T11:00:00.000Z | 2022-06-02T12:00:00.000Z | 4FS |
| 6 | · Zaplacení zálohové faktury | 1 | day | 0 | 2022-06-03T13:00:00.000Z | 2022-06-06T13:00:00.000Z | 24FS |
| 7 | · Zaplacení finální faktury | 1 | day | 0 | 2022-06-23T11:00:00.000Z | 2022-06-24T10:00:00.000Z | 26FS |
| 8 | Graficko-technické oddělení | 52.375 | day | 0 | 2022-04-05T07:00:00.000Z | 2022-06-16T10:00:00.000Z |  |
| 9 | · Návrh materiálů na použití | 1 | day | 0 | 2022-04-05T07:00:00.000Z | 2022-04-06T07:00:00.000Z | 3FS |
| 51 | · Návrh rozkresů | 7 | day | 0 | 2022-04-06T07:00:00.000Z | 2022-04-15T07:00:00.000Z | 9FS |
| 11 | · Vizualizace finálního produktu | 3 | day | 0 | 2022-04-15T07:00:00.000Z | 2022-04-20T07:00:00.000Z | 51FS |
| 12 | · Tvorba prezentace | 1 | day | 0 | 2022-04-20T07:00:00.000Z | 2022-04-21T07:00:00.000Z | 22FS,11FS |
| 13 | · Předvedení zákazníkovi | 3 | hour | 0 | 2022-04-21T07:00:00.000Z | 2022-04-21T10:00:00.000Z | 12FS |
| 14 | · Tvorba grafických podkladů | 7 | day | 0 | 2022-06-02T12:00:00.000Z | 2022-06-13T12:00:00.000Z | 5FS |
| 15 | · Odeslání podkladů na frézu | 1 | hour | 0 | 2022-06-13T12:00:00.000Z | 2022-06-13T13:00:00.000Z | 14FS |
| 16 | · Odeslání podkladů na laser | 1 | hour | 0 | 2022-06-13T12:00:00.000Z | 2022-06-13T13:00:00.000Z | 14FS |
| 17 | · Odeslání podkladů na kovovýrobu | 1 | hour | 0 | 2022-06-13T12:00:00.000Z | 2022-06-13T13:00:00.000Z | 14FS |
| 18 | · Vytvoření přesných rozměrů pro tisk | 1 | day | 0 | 2022-06-15T09:00:00.000Z | 2022-06-16T09:00:00.000Z | 32FS |
| 19 | · Zaslání dat na plotr | 1 | hour | 0 | 2022-06-16T09:00:00.000Z | 2022-06-16T10:00:00.000Z | 18FS |
| 20 | Obchodní oddělení | 56.375 | day | 0 | 2022-04-06T07:00:00.000Z | 2022-06-23T10:00:00.000Z |  |
| 21 | · Zajištění odstupnosti materiálů | 2 | day | 0 | 2022-04-06T07:00:00.000Z | 2022-04-08T07:00:00.000Z | 9FS |
| 22 | · Kalkulace ceny materiálu | 1 | day | 0 | 2022-04-08T07:00:00.000Z | 2022-04-11T07:00:00.000Z | 21FS |
| 23 | · Tvorba finální kalkulace + záloha | 1 | day | 0 | 2022-06-02T12:00:00.000Z | 2022-06-03T12:00:00.000Z | 5FS |
| 24 | · Odeslání zálohové faktury | 1 | hour | 0 | 2022-06-03T12:00:00.000Z | 2022-06-03T13:00:00.000Z | 23FS |
| 25 | · Vytvoření finální faktury | 1 | hour | 0 | 2022-06-23T08:00:00.000Z | 2022-06-23T09:00:00.000Z | 50FS |
| 26 | · Odeslání finální faktury zákazníkovi | 1 | hour | 0 | 2022-06-23T09:00:00.000Z | 2022-06-23T10:00:00.000Z | 25FS |
| 27 | Produkční oddělení | 6.75 | day | 0 | 2022-06-13T13:00:00.000Z | 2022-06-22T10:00:00.000Z |  |
| 28 | · Fréza a laser | 1.75 | day | 0 | 2022-06-13T13:00:00.000Z | 2022-06-15T10:00:00.000Z |  |
| 29 | · · Vypalování kovových částí | 1 | day | 0 | 2022-06-13T13:00:00.000Z | 2022-06-14T13:00:00.000Z | 15FS |
| 30 | · · Frézování jednotlivých částí | 1 | day | 0 | 2022-06-13T13:00:00.000Z | 2022-06-14T13:00:00.000Z | 15FS |
| 31 | · · Složení korpusu | 4 | hour | 0 | 2022-06-14T13:00:00.000Z | 2022-06-15T08:00:00.000Z | 30FS |
| 32 | · · Vytvoření přesných rozměrů korpusu | 1 | hour | 0 | 2022-06-15T08:00:00.000Z | 2022-06-15T09:00:00.000Z | 31FS |
| 34 | · · Přesunutí korpusů na plotr | 1 | hour | 0 | 2022-06-15T09:00:00.000Z | 2022-06-15T10:00:00.000Z | 32FS |
| 33 | · Tiskové oddělení | 1.625 | day | 0 | 2022-06-16T11:00:00.000Z | 2022-06-20T07:00:00.000Z |  |
| 35 | · · Tisk jednotlivých polepů | 4 | hour | 0 | 2022-06-16T11:00:00.000Z | 2022-06-16T15:00:00.000Z | 19FS |
| 36 | · · Polep korpusů | 1 | day | 0 | 2022-06-17T06:00:00.000Z | 2022-06-17T15:00:00.000Z | 34FS,35FS |
| 37 | · · Přesunutí korpusů na dílnu | 1 | hour | 0 | 2022-06-20T06:00:00.000Z | 2022-06-20T07:00:00.000Z | 36FS |
| 38 | · Kovovýroba | 6.75 | day | 0 | 2022-06-13T13:00:00.000Z | 2022-06-22T10:00:00.000Z |  |
| 39 | · · Tvorba kovové konstrukce | 2 | day | 0 | 2022-06-13T13:00:00.000Z | 2022-06-15T13:00:00.000Z | 17FS |
| 40 | · · Tvorba dílčích komponent | 1 | day | 0 | 2022-06-15T13:00:00.000Z | 2022-06-16T13:00:00.000Z | 29FS,39FS |
| 41 | · · Elektroinstalace | 5 | hour | 0 | 2022-06-20T07:00:00.000Z | 2022-06-20T13:00:00.000Z | 37FS,40FS |
| 42 | · · Finální složení | 4 | hour | 0 | 2022-06-20T13:00:00.000Z | 2022-06-21T08:00:00.000Z | 41FS |
| 43 | · · Rozebrání na menší části | 4 | hour | 0 | 2022-06-21T08:00:00.000Z | 2022-06-21T13:00:00.000Z | 42FS |
| 44 | · · Příprava k převozu (zabalení) | 3 | hour | 0 | 2022-06-21T13:00:00.000Z | 2022-06-22T07:00:00.000Z | 43FS |
| 45 | · · Naložení do auta | 1 | hour | 0 | 2022-06-22T07:00:00.000Z | 2022-06-22T08:00:00.000Z | 44FS |
| 46 | · · Odvoz na letiště | 2 | hour | 0 | 2022-06-22T08:00:00.000Z | 2022-06-22T10:00:00.000Z | 45FS |
| 47 | Letiště | 0.75 | day | 0 | 2022-06-22T11:00:00.000Z | 2022-06-23T08:00:00.000Z |  |
| 48 | · Sestavení na místě určení | 4 | hour | 0 | 2022-06-22T11:00:00.000Z | 2022-06-22T15:00:00.000Z | 46FS |
| 49 | · Předání zákazníkovi | 1 | hour | 0 | 2022-06-23T06:00:00.000Z | 2022-06-23T07:00:00.000Z | 48FS |
| 50 | · Kontaktování obch. oddělení | 1 | hour | 0 | 2022-06-23T07:00:00.000Z | 2022-06-23T08:00:00.000Z | 49FS |
