| TaskID | TaskName | StartDate | EndDate | Duration | Progress | DurationUnit | Predecessor |
| --- | --- | --- | --- | --- | --- | --- | --- |
| 1 | Zákazník | 2022-04-01T06:00:00.000Z | 2022-08-24T15:00:00.000Z | 104 | 0 | day |  |
| 2 | · Vytvoření zakázky | 2022-04-01T06:00:00.000Z | 2022-04-04T15:00:00.000Z | 2 | 0 | day |  |
| 3 | · Odeslání všech potřebných podkladů | 2022-04-05T06:00:00.000Z | 2022-04-05T07:00:00.000Z | 1 | 0 | hour | 2FS |
| 4 | · Schválení prezentace | 2022-04-21T11:00:00.000Z | 2022-05-19T10:00:00.000Z | 20 | 0 | day | 16FS |
| 5 | · Úprava požadavků zakázky | 2022-05-19T11:00:00.000Z | 2022-05-24T10:00:00.000Z | 3 | 0 | day | 4FS |
| 6 | · Odeslání všech potřebných podkladů | 2022-05-24T11:00:00.000Z | 2022-05-24T12:00:00.000Z | 1 | 0 | hour | 5FS |
| 7 | · Schválení prezentace | 2022-06-10T06:00:00.000Z | 2022-07-21T15:00:00.000Z | 30 | 0 | day | 22FS |
| 8 | · Kontaktování dodavatele | 2022-07-22T06:00:00.000Z | 2022-07-22T07:00:00.000Z | 1 | 0 | hour | 7FS |
| 9 | · Zaplacení zálohové faktury | 2022-07-25T08:00:00.000Z | 2022-07-26T08:00:00.000Z | 1 | 0 | day | 40FS |
| 10 | · Zaplacení finální faktury | 2022-08-24T06:00:00.000Z | 2022-08-24T15:00:00.000Z | 1 | 0 | day | 43FS |
| 11 | Graficko-technické oddělení | 2022-04-05T07:00:00.000Z | 2022-08-12T08:00:00.000Z | 93.125 | 0 | day |  |
| 12 | · Návrh materiálů na použití | 2022-04-05T07:00:00.000Z | 2022-04-06T07:00:00.000Z | 1 | 0 | day | 3FS |
| 13 | · Návrh rozkresů | 2022-04-06T07:00:00.000Z | 2022-04-15T07:00:00.000Z | 7 | 0 | day | 12FS |
| 14 | · Vizualizace finálního produktu | 2022-04-15T07:00:00.000Z | 2022-04-20T07:00:00.000Z | 3 | 0 | day | 13FS |
| 17 | · Návrh materiálů na použití | 2022-04-08T08:00:00.000Z | 2022-04-11T08:00:00.000Z | 1 | 0 | day | 32FS |
| 15 | · Tvorba prezentace | 2022-04-20T07:00:00.000Z | 2022-04-21T07:00:00.000Z | 1 | 0 | day | 34FS,14FS |
| 16 | · Předvedení zákazníkovi | 2022-04-21T07:00:00.000Z | 2022-04-21T10:00:00.000Z | 3 | 0 | hour | 15FS |
| 24 | · Návrh materiálů na použití | 2022-05-24T12:00:00.000Z | 2022-05-25T12:00:00.000Z | 1 | 0 | day | 6FS |
| 26 | · Návrh rozkresů | 2022-05-25T12:00:00.000Z | 2022-06-03T12:00:00.000Z | 7 | 0 | day | 24FS |
| 27 | · Vizualizace finálního produktu | 2022-06-03T12:00:00.000Z | 2022-06-08T12:00:00.000Z | 3 | 0 | day | 26FS |
| 18 | · Návrh materiálů na použití | 2022-05-27T13:00:00.000Z | 2022-05-30T13:00:00.000Z | 1 | 0 | day | 36FS |
| 21 | · Tvorba prezentace | 2022-06-08T12:00:00.000Z | 2022-06-09T12:00:00.000Z | 1 | 0 | day | 38FS,27FS |
| 22 | · Předvedení zákazníkovi | 2022-06-09T12:00:00.000Z | 2022-06-09T15:00:00.000Z | 3 | 0 | hour | 21FS |
| 23 | · Tvorba grafických podkladů | 2022-07-22T07:00:00.000Z | 2022-08-02T07:00:00.000Z | 7 | 0 | day | 8FS |
| 47 | · Odeslání podkladů na frézu | 2022-08-02T07:00:00.000Z | 2022-08-02T08:00:00.000Z | 1 | 0 | hour | 23FS |
| 48 | · Odeslání podkladů na laser | 2022-08-02T07:00:00.000Z | 2022-08-02T08:00:00.000Z | 1 | 0 | hour | 23FS |
| 49 | · Odeslání podkladů na kovovýrobu | 2022-08-02T07:00:00.000Z | 2022-08-02T08:00:00.000Z | 1 | 0 | hour | 23FS |
| 50 | · Vytvoření nových podkladů na frézu | 2022-08-03T13:00:00.000Z | 2022-08-04T13:00:00.000Z | 1 | 0 | day | 58FS |
| 51 | · Odeslání podkladů na frézu | 2022-08-04T13:00:00.000Z | 2022-08-04T14:00:00.000Z | 1 | 0 | hour | 50FS |
| 52 | · Vytvoření přesných rozměrů pro tisk | 2022-08-08T11:00:00.000Z | 2022-08-09T10:00:00.000Z | 1 | 0 | day | 61FS |
| 53 | · Zaslání dat na plotr | 2022-08-09T11:00:00.000Z | 2022-08-09T12:00:00.000Z | 1 | 0 | hour | 52FS |
| 54 | · Vytvoření nových grafický fat na plotr | 2022-08-11T07:00:00.000Z | 2022-08-12T07:00:00.000Z | 1 | 0 | day | 65FS |
| 55 | · Zaslání dat na plotr | 2022-08-12T07:00:00.000Z | 2022-08-12T08:00:00.000Z | 1 | 0 | hour | 54FS |
| 30 | Obchodní oddělení | 2022-04-06T07:00:00.000Z | 2022-08-23T15:00:00.000Z | 99.875 | 0 | day |  |
| 31 | · Zajištění odstupnosti materiálů | 2022-04-06T07:00:00.000Z | 2022-04-08T07:00:00.000Z | 2 | 0 | day | 12FS |
| 32 | · Kontaktování GT oddělení | 2022-04-08T07:00:00.000Z | 2022-04-08T08:00:00.000Z | 1 | 0 | hour | 31FS |
| 33 | · Zajištění odstupnosti materiálů | 2022-04-11T08:00:00.000Z | 2022-04-13T08:00:00.000Z | 2 | 0 | day | 17FS |
| 34 | · Kalkulace ceny materiálu | 2022-04-13T08:00:00.000Z | 2022-04-14T08:00:00.000Z | 1 | 0 | day | 33FS |
| 35 | · Zajištění odstupnosti materiálů | 2022-05-25T12:00:00.000Z | 2022-05-27T12:00:00.000Z | 2 | 0 | day | 24FS |
| 36 | · Kontaktování GT oddělení | 2022-05-27T12:00:00.000Z | 2022-05-27T13:00:00.000Z | 1 | 0 | hour | 35FS |
| 37 | · Zajištění odstupnosti materiálů | 2022-05-30T13:00:00.000Z | 2022-06-01T13:00:00.000Z | 2 | 0 | day | 18FS |
| 38 | · Kalkulace ceny materiálu | 2022-06-01T13:00:00.000Z | 2022-06-02T13:00:00.000Z | 1 | 0 | day | 37FS |
| 39 | · Tvorba finální kalkulace + záloha | 2022-07-22T07:00:00.000Z | 2022-07-25T07:00:00.000Z | 1 | 0 | day | 8FS |
| 40 | · Odeslání zálohové faktury | 2022-07-25T07:00:00.000Z | 2022-07-25T08:00:00.000Z | 1 | 0 | hour | 39FS |
| 41 | · Vytvoření finální faktury | 2022-08-22T14:00:00.000Z | 2022-08-22T15:00:00.000Z | 1 | 0 | hour | 85FS |
| 42 | · Vytvoření faktury ohledně doplatku | 2022-08-22T14:00:00.000Z | 2022-08-22T15:00:00.000Z | 1 | 0 | hour | 85FS |
| 43 | · Odeslání finální faktury zákazníkovi | 2022-08-23T06:00:00.000Z | 2022-08-23T15:00:00.000Z | 1 | 0 | day | 41FS,42FS |
| 44 | Produkční oddělení | 2022-08-02T08:00:00.000Z | 2022-08-19T13:00:00.000Z | 13.5 | 0 | day |  |
| 45 | · Fréza a laser | 2022-08-02T08:00:00.000Z | 2022-08-08T12:00:00.000Z | 4.375 | 0 | day |  |
| 56 | · · Vypalování kovových částí | 2022-08-02T08:00:00.000Z | 2022-08-03T08:00:00.000Z | 1 | 0 | day | 48FS |
| 57 | · · Frézování jednotlivých částí | 2022-08-02T08:00:00.000Z | 2022-08-03T08:00:00.000Z | 1 | 0 | day | 47FS |
| 58 | · · Složení korpusu | 2022-08-03T08:00:00.000Z | 2022-08-03T13:00:00.000Z | 4 | 0 | hour | 57FS |
| 59 | · · Frézování jednotlivých částí | 2022-08-04T14:00:00.000Z | 2022-08-05T14:00:00.000Z | 1 | 0 | day | 51FS |
| 60 | · · Složení korpusu | 2022-08-05T14:00:00.000Z | 2022-08-08T09:00:00.000Z | 4 | 0 | hour | 59FS |
| 61 | · · Vytvoření přesných rozměrů korpusu | 2022-08-08T09:00:00.000Z | 2022-08-08T10:00:00.000Z | 1 | 0 | hour | 60FS |
| 62 | · · Přesunutí korpusů na plotr | 2022-08-08T11:00:00.000Z | 2022-08-08T12:00:00.000Z | 1 | 0 | hour | 61FS |
| 63 | · Tiskové oddělení | 2022-08-09T12:00:00.000Z | 2022-08-15T14:00:00.000Z | 4.25 | 0 | day |  |
| 64 | · · Tisk jednotlivých polepů | 2022-08-09T12:00:00.000Z | 2022-08-10T07:00:00.000Z | 4 | 0 | hour | 53FS |
| 65 | · · Polep korpusů | 2022-08-10T07:00:00.000Z | 2022-08-11T07:00:00.000Z | 1 | 0 | day | 64FS |
| 66 | · · Tisk jednotlivých polepů | 2022-08-12T08:00:00.000Z | 2022-08-12T13:00:00.000Z | 4 | 0 | hour | 55FS |
| 67 | · · Polep korpusů | 2022-08-12T13:00:00.000Z | 2022-08-15T13:00:00.000Z | 1 | 0 | day | 66FS,62FS |
| 68 | · · Přesunutí korpusů na dílnu | 2022-08-15T13:00:00.000Z | 2022-08-15T14:00:00.000Z | 1 | 0 | hour | 67FS |
| 69 | · Kovovýroba | 2022-08-02T08:00:00.000Z | 2022-08-19T13:00:00.000Z | 13.5 | 0 | day |  |
| 70 | · · Tvorba kovové konstrukce | 2022-08-02T08:00:00.000Z | 2022-08-04T08:00:00.000Z | 2 | 0 | day | 49FS |
| 71 | · · Tvorba dílčích komponent | 2022-08-04T08:00:00.000Z | 2022-08-05T08:00:00.000Z | 1 | 0 | day | 70FS,56FS |
| 72 | · · Elektroinstalace | 2022-08-15T14:00:00.000Z | 2022-08-16T10:00:00.000Z | 5 | 0 | hour | 71FS,68FS |
| 73 | · · Finální složení | 2022-08-16T11:00:00.000Z | 2022-08-16T15:00:00.000Z | 4 | 0 | hour | 72FS |
| 74 | · · Oprava chyb | 2022-08-17T06:00:00.000Z | 2022-08-17T15:00:00.000Z | 1 | 0 | day | 73FS |
| 75 | · · Finální složení | 2022-08-18T06:00:00.000Z | 2022-08-18T10:00:00.000Z | 4 | 0 | hour | 74FS |
| 76 | · · Rozebrání na menší části | 2022-08-18T11:00:00.000Z | 2022-08-18T15:00:00.000Z | 4 | 0 | hour | 75FS |

| TaskID | TaskName | StartDate | EndDate | Duration | Progress | DurationUnit | Predecessor |
| --- | --- | --- | --- | --- | --- | --- | --- |
| 77 | · · Příprava k převozu (zabalení) | 2022-08-19T06:00:00.000Z | 2022-08-19T09:00:00.000Z | 3 | 0 | hour | 76FS |
| 78 | · · Naložení do auta | 2022-08-19T09:00:00.000Z | 2022-08-19T10:00:00.000Z | 1 | 0 | hour | 77FS |
| 79 | · · Odvoz na letiště | 2022-08-19T11:00:00.000Z | 2022-08-19T13:00:00.000Z | 2 | 0 | hour | 78FS |
| 80 | Letiště | 2022-08-19T13:00:00.000Z | 2022-08-22T14:00:00.000Z | 1.125 | 0 | day |  |
| 81 | · Sestavení na místě určení | 2022-08-19T13:00:00.000Z | 2022-08-22T08:00:00.000Z | 4 | 0 | hour | 79FS |
| 82 | · Oprava chyb při sestavení | 2022-08-22T08:00:00.000Z | 2022-08-22T10:00:00.000Z | 2 | 0 | hour | 81FS |
| 83 | · Vytvoření reportu ohledně vyskytnutých chyb | 2022-08-22T11:00:00.000Z | 2022-08-22T12:00:00.000Z | 1 | 0 | hour | 82FS |
| 84 | · Předání zákazníkovi | 2022-08-22T12:00:00.000Z | 2022-08-22T13:00:00.000Z | 1 | 0 | hour | 83FS |
| 85 | · Kontaktování obch. oddělení | 2022-08-22T13:00:00.000Z | 2022-08-22T14:00:00.000Z | 1 | 0 | hour | 84FS |
